# GD-10 - dakopbouw+afschotlaag

Schedule from MS Project, 2003-01-12 to 2003-02-10, status date 2003-01-08.
BAM Nelissen Van Egteren

## Calendars

- ALLEEN WERKDAGEN: Mon-Fri 08:30-12:30, 13:00-17:00; Sat-Sun off. Exceptions (off unless hours are given): 2003-01-11 to 2003-01-12 08:30-12:30, 13:00-17:00, 2003-01-18 to 2003-01-19 08:30-12:30, 13:00-17:00, 2003-01-25 to 2003-01-26 08:30-12:30, 13:00-17:00, 2003-02-01 to 2003-02-02 08:30-12:30, 13:00-17:00, 2003-02-08 to 2003-02-09 08:30-12:30, 13:00-17:00.

## Schedule

| ID | WBS | Task | Type | Duration | Start | Finish | Predecessors | Total slack | Free slack |
| --- | --- | --- | --- | --- | --- | --- | --- | --- | --- |
| 1 | 1 | **GEVEL/DAK FASE** |  | 30d | 2003-01-12 | 2003-02-10 |  | 0d |  |
| 2 | 1.1 | gevel prefab elementen mont. |  | 10d | 2003-01-12 | 2003-01-21 |  | 0d |  |
| 3 | 1.2 | gevel kozijnen monteren |  | 5d | 2003-01-22 | 2003-01-26 | 2SS+10d | 12d | 0d |
| 4 | 1.3 | gevel kozijnen glas plaatsen |  | 5d | 2003-01-25 | 2003-01-29 | 3SS+3d | 12d |  |
| 5 | 1.4 | dak randen +opstortingen |  | 5d | 2003-01-12 | 2003-01-16 | 2SS | 0d |  |
| 6 | 1.5 | dakopbouw staalconstructie |  | 5d | 2003-01-15 | 2003-01-19 | 5SS+3d | 0d |  |
| 7 | 1.6 | dakopbouw gevelplaten |  | 5d | 2003-01-19 | 2003-01-23 | 6SS+4d | 0d |  |
| 8 | 1.7 | dakopbouw dakplaten |  | 5d | 2003-01-22 | 2003-01-26 | 7SS+3d | 0d |  |
| 9 | 1.8 | dakopbouw dakisolatie+bedekking |  | 5d | 2003-01-25 | 2003-01-29 | 8SS+3d | 0d |  |
| 10 | 1.9 | platdak cement afschotlaag |  | 5d | 2003-01-28 | 2003-02-01 | 9SS+3d | 0d |  |
| 11 | 1.10 | droogtijd afschotlaag |  | 5d | 2003-01-31 | 2003-02-04 | 10SS+3d | 0d |  |
| 12 | 1.11 | dak isolatieplaten aanbrengen |  | 5d | 2003-02-03 | 2003-02-07 | 11SS+3d | 0d |  |
| 13 | 1.12 | dak bedekking aanbrengen |  | 5d | 2003-02-06 | 2003-02-10 | 12SS+3d | 0d |  |
| 14 | 1.13 | start afbouw fase | milestone | 0d | 2003-02-10 | 2003-02-10 | 13SS+5d | 0d |  |
